# פעילויות שלב הבקשה להצעות

Schedule from MS Project, 2003-01-01 to 2003-06-23, 8.5 hours a day.
<שם המערכת>
<שם הארגון>

## Calendars

- Standard: Mon-Thu 08:00-12:00, 12:30-17:00; Fri-Sat off; Sun 08:00-12:00, 12:30-17:00.

## Resources

| Resource |
| --- |
| מנהל פרוייקט |
| ועדת היגוי |
| צוות ישומי |
| צוות טכנולוגי |
| צוות התקשרות |
| יעוץ משפטי |

## Schedule

| ID | WBS | Task | Type | Duration | Start | Finish | Predecessors | Total slack | Free slack | Resources | Work |
| --- | --- | --- | --- | --- | --- | --- | --- | --- | --- | --- | --- |
| 1 | 1 | **המפרט** |  | 27d | 2003-01-01 | 2003-02-09 |  | 0d |  |  | 535.5h |
| 2 | 1.1 | בדיקת תיק האפיון |  | 5d | 2003-01-01 | 2003-01-08 |  | 116d | 0d | מנהל פרוייקט | 42.5h |
| 3 | 1.2 | אישור מוכנות תיק אפיון להוצאת בקשה להצעות | milestone | 0d | 2003-01-08 | 2003-01-08 | 2 | 116d | 0d | מנהל פרוייקט |  |
| 4 | 1.3 | **גיבוש וציוות הגורמים המעורבים** |  | 2d | 2003-01-01 | 2003-01-05 |  | 0d |  |  | 34h |
| 5 | 1.3.1 | גיבוש ועדת ההיגוי / הצוות המינהלי |  | 2d | 2003-01-01 | 2003-01-05 |  | 0d |  | מנהל פרוייקט | 17h |
| 6 | 1.3.2 | בחירת הצוות המקצועי |  | 2d | 2003-01-01 | 2003-01-05 |  | 121d |  | מנהל פרוייקט | 17h |
| 7 | 1.4 | בניית תוכנית עבודה |  | 2d | 2003-01-08 | 2003-01-12 | 3 | 116d |  | מנהל פרוייקט | 17h |
| 8 | 1.5 | החלטה על צורת הפנייה לספקים |  | 1d | 2003-01-05 | 2003-01-06 | 5 | 0d |  | ועדת היגוי | 8.5h |
| 9 | 1.6 | קביעת שיטת המכרז |  | 1d | 2003-01-06 | 2003-01-07 | 8 | 0d |  | ועדת היגוי | 8.5h |
| 10 | 1.7 | **כתיבת המפרט** |  | 3d | 2003-01-07 | 2003-01-12 |  | 0d |  |  | 110.5h |
| 11 | 1.7.1 | הכנת המסמכים הפנימיים לבדיקה - מפל |  | 2d | 2003-01-07 | 2003-01-09 | 9 | 117d |  | ועדת היגוי | 17h |
| 12 | 1.7.2 | כתיבת פרק המנהלה |  | 2d | 2003-01-07 | 2003-01-09 | 9 | 0d |  | מנהל פרוייקט | 17h |
| 13 | 1.7.3 | סיווג פרק ישום |  | 2d | 2003-01-07 | 2003-01-09 | 9 | 0d |  | צוות ישומי | 17h |
| 14 | 1.7.4 | סיווג פרק טכנולוגייה |  | 2d | 2003-01-07 | 2003-01-09 | 9 | 0d |  | צוות טכנולוגי | 17h |
| 15 | 1.7.5 | סיווג פרק המימוש |  | 2d | 2003-01-07 | 2003-01-09 | 9 | 0d |  | מנהל פרוייקט | 17h |
| 16 | 1.7.6 | כתיבת פרק העלות |  | 2d | 2003-01-07 | 2003-01-09 | 9 | 0d |  | מנהל פרוייקט | 17h |
| 17 | 1.7.7 | אישור מסמך RFP |  | 1d | 2003-01-09 | 2003-01-12 | 16, 12, 13, 14, 15 | 0d |  | מנהל פרוייקט | 8.5h |
| 18 | 1.7.8 | החלטה סופית על יציאה למכרז | milestone | 0d | 2003-01-12 | 2003-01-12 | 17 | 0d |  | ועדת היגוי |  |
| 19 | 1.8 | **הוצאת המפרט** |  | 20d | 2003-01-12 | 2003-02-09 |  | 0d |  |  | 314.5h |
| 20 | 1.8.1 | הדפסות ואריזה |  | 5d | 2003-01-12 | 2003-01-19 | 18 | 0d |  | מנהל פרוייקט | 42.5h |
| 21 | 1.8.2 | פרסום ברשומות/בעיתונות/באתר מתאים |  | 3d | 2003-01-19 | 2003-01-22 | 20 | 108d |  | מנהל פרוייקט | 25.5h |
| 22 | 1.8.3 | חלוקה והפצה |  | 5d | 2003-01-19 | 2003-01-26 | 20 | 0d |  | מנהל פרוייקט | 42.5h |
| 23 | 1.8.4 | ניהול רשימת הספקים שקבלו את המפרט |  | 2d | 2003-01-26 | 2003-01-28 | 22 | 0d |  | מנהל פרוייקט | 17h |
| 24 | 1.8.5 | מענה לשאלות ספקים בכתב |  | 7d | 2003-01-28 | 2003-02-06 | 23 | 0d |  | מנהל פרוייקט; צוות ישומי; צוות טכנולוגי | 178.5h |
| 25 | 1.8.6 | עריכת כנס ספקים |  | 1d | 2003-02-06 | 2003-02-09 | 24 | 0d |  | מנהל פרוייקט | 8.5h |

| ID | WBS | Task | Type | Duration | Start | Finish | Predecessors | Total slack | Resources | Work |
| --- | --- | --- | --- | --- | --- | --- | --- | --- | --- | --- |
| 26 | 2 | **בדיקת ההצעות** |  | 60d | 2003-02-16 | 2003-05-11 |  | 0d |  | 858.5h |
| 27 | 2.1 | פתיחת תיבת מכרזים | milestone | 0d | 2003-02-16 | 2003-02-16 | 25FS+5d | 0d | ועדת היגוי |  |
| 28 | 2.2 | **של ההצעות I בדיקה** |  | 3d | 2003-02-16 | 2003-02-19 |  | 0d |  | 25.5h |
| 29 | 2.2.1 | סינון ראשוני לפי רכיבי סף שהוגדרו במפל |  | 3d | 2003-02-16 | 2003-02-19 | 27 | 0d | מנהל פרוייקט | 25.5h |
| 30 | 2.2.2 | אישור הסינון הראשוני | milestone | 0d | 2003-02-19 | 2003-02-19 | 29 | 0d | ועדת היגוי |  |
| 31 | 2.3 | **של ההצעות II בדיקה** |  | 13d | 2003-02-19 | 2003-03-10 |  | 0d |  | 195.5h |
| 32 | 2.3.1 | קריאה יסודית של ההצעות שעברו סינון ראשוני |  | 5d | 2003-02-19 | 2003-02-26 | 30 | 0d | מנהל פרוייקט | 42.5h |
| 33 | 2.3.2 | סינון רכיבי סף מדרגה 2 |  | 3d | 2003-02-26 | 2003-03-03 | 32 | 0d | מנהל פרוייקט | 25.5h |
| 34 | 2.3.3 | הבהרות ומצגות |  | 5d | 2003-03-03 | 2003-03-10 | 33 | 0d | מנהל פרוייקט; צוות ישומי; צוות טכנולוגי | 127.5h |
| 35 | 2.4 | **הערכות, מתן ציונים וסיכומים** |  | 44d | 2003-03-10 | 2003-05-11 |  | 0d |  | 637.5h |
| 36 | 2.4.1 | סיכום פרק היישום |  | 10d | 2003-03-10 | 2003-03-24 | 34 | 0d | מנהל פרוייקט; צוות ישומי | 170h |
| 37 | 2.4.2 | סיכום פרק הטכנולוגיה |  | 10d | 2003-03-24 | 2003-04-07 | 36 | 0d | מנהל פרוייקט; צוות טכנולוגי | 170h |
| 38 | 2.4.3 | סיכום פרק המימוש |  | 10d | 2003-04-07 | 2003-04-21 | 37 | 0d | מנהל פרוייקט | 85h |
| 39 | 2.4.4 | סיכום פרק העלות |  | 5d | 2003-04-21 | 2003-04-28 | 38 | 0d | ועדת היגוי; מנהל פרוייקט | 85h |
| 40 | 2.4.5 | סיכומים והערכות סופיות |  | 4d | 2003-04-28 | 2003-05-04 | 39 | 0d | מנהל פרוייקט; ועדת היגוי | 68h |
| 41 | 2.4.6 | בדיקה השוואתית של אמידת העלויות מול הצעות הספקים |  | 2d | 2003-05-04 | 2003-05-06 | 40 | 0d | מנהל פרוייקט; ועדת היגוי | 34h |
| 42 | 2.4.7 | החלטה |  | 2d | 2003-05-06 | 2003-05-08 | 41 | 0d | ועדת היגוי | 17h |
| 43 | 2.4.8 | יידוע גורמים נוספים |  | 1d | 2003-05-08 | 2003-05-11 | 42 | 31d | ועדת היגוי | 8.5h |
| 44 | 3 | **ההתקשרות** |  | 32d | 2003-05-08 | 2003-06-23 |  | 0d |  | 493h |
| 45 | 3.1 | מינוי צוות לקיום פגישות וסיכום ההתקשרות עם הספק |  | 2d | 2003-05-08 | 2003-05-12 | 42 | 0d | ועדת היגוי | 17h |
| 46 | 3.2 | גיבוש נקודות לדיון לקראת הפגישות עם נציגי הספק |  | 4d | 2003-05-12 | 2003-05-18 | 45 | 0d | צוות התקשרות | 34h |
| 47 | 3.3 | סגירת החוזה ותיק המערכת |  | 10d | 2003-05-18 | 2003-06-01 | 46 | 0d | צוות התקשרות; יעוץ משפטי | 170h |
| 48 | 3.4 | תיקונים ושינויים - שיפור ההצעה |  | 10d | 2003-06-01 | 2003-06-15 | 47 | 0d | צוות התקשרות; יעוץ משפטי | 170h |
| 49 | 3.5 | אישור ההתקשרות והמשך הפרויקט |  | 3d | 2003-06-15 | 2003-06-18 | 48 | 0d | ועדת היגוי; יעוץ משפטי | 51h |
| 50 | 3.6 | ביצוע התקשרות עם הספק/ים |  | 3d | 2003-06-18 | 2003-06-23 | 49 | 0d | יעוץ משפטי; ועדת היגוי | 51h |
| 51 | 3.7 | חתימה על חוזה והוצאת הזמנת עבודה | milestone | 0d | 2003-06-23 | 2003-06-23 | 50 | 0d | ועדת היגוי; יעוץ משפטי |  |
