# נספח 4.2 תוכנית עבודה

Schedule from MS Project, 2005-03-02 to 2005-03-29.
<שם המערכת>
<שם הארגון>

## Calendars

- Standard: Mon-Fri 08:00-12:00, 13:00-17:00; Sat-Sun off.

## Resources

| Resource |
| --- |
| מנהל הפרויקט |
| מנתח המערכת |
| צוות הפרויקט |
| מומחה היישום |
| ועדת היגוי |
| אבטחת איכות |
| מהנדס הפרויקט |
| מנ |

## Schedule

| ID | WBS | Task | Type | Duration | Start | Finish | Predecessors | Total slack | Free slack | Resources | Work |
| --- | --- | --- | --- | --- | --- | --- | --- | --- | --- | --- | --- |
| 1 | 1 | **התארגנות** |  | 4d? | 2005-03-02 | 2005-03-07 |  | 0d |  | מנהל הפרויקט | 64h |
| 2 | 1.1 | ארגון תיק האפיון ותיקיית הפרויקט |  | 1d? | 2005-03-02 | 2005-03-02 |  | 0d |  | מנהל הפרויקט | 8h |
| 3 | 1.2 | גיבוש הצוותים |  | 1d? | 2005-03-03 | 2005-03-03 | 2 | 0d |  | מנהל הפרויקט | 8h |
| 4 | 1.3 | העמדת מחשב לפיתוח המערכת |  | 1d? | 2005-03-04 | 2005-03-04 | 3 | 0d |  | מנהל הפרויקט | 8h |
| 5 | 1.4 | בניית תוכנית עבודה לשלב האפיון עצמו |  | 1d? | 2005-03-07 | 2005-03-07 | 4 | 0d |  | מנהל הפרויקט | 8h |
| 6 | 2 | **אפיון - מעבר ראשון** |  | 8d? | 2005-03-08 | 2005-03-17 | 5 | 0d |  | מנתח המערכת | 168h |
| 7 | 2.1 | ראיון נציגות המשרד והלקוח העיקרי |  | 1d? | 2005-03-08 | 2005-03-08 | 5 | 0d |  | מנתח המערכת | 8h |
| 8 | 2.2 | איסוף כל חומר כתוב ולימודו |  | 1d? | 2005-03-09 | 2005-03-09 | 7 | 0d |  | מנתח המערכת | 8h |
| 9 | 2.3 | לימוד ותיעוד מצב קיים |  | 1d? | 2005-03-10 | 2005-03-10 | 8 | 0d |  | מנתח המערכת | 8h |
| 10 | 2.4 | ניהול תצורה ואבטחת איכות |  | 1d? | 2005-03-08 | 2005-03-08 | 5 | 15d |  | אבטחת איכות | 8h |
| 11 | 2.5 | סיכוני אבטחת מידע - בממ |  | 1d? | 2005-03-11 | 2005-03-11 | 9 | 12d |  | מהנדס הפרויקט | 8h |
| 12 | 2.6 | הגדרה סופית של רכיב היעדים |  | 1d? | 2005-03-11 | 2005-03-11 | 9 | 0d |  | מנתח המערכת | 8h |
| 13 | 2.7 | חלוקה כללית לתת-מערכות - תיחום פנימי |  | 1d? | 2005-03-14 | 2005-03-14 | 12 | 0d |  | מנתח המערכת | 8h |
| 14 | 2.8 | קביעת המשתמשים - שיקוף |  | 1d? | 2005-03-15 | 2005-03-15 | 13 | 8d | 0d | ועדת היגוי | 8h |
| 15 | 2.9 | סבב ראיונות ראשון |  | 1d? | 2005-03-15 | 2005-03-15 | 13 | 0d |  | מנתח המערכת | 8h |
| 16 | 2.10 | סיכום ראשון של הנתונים - ניתוח מערכת I |  | 1d? | 2005-03-16 | 2005-03-16 | 14 | 8d | 0d | מנתח המערכת | 8h |
| 17 | 2.11 | בניית עץ המערכת הפרטי - מבנה תיק האפיון הסופי |  | 1d? | 2005-03-16 | 2005-03-16 | 15 | 0d |  | מנתח המערכת | 8h |
| 18 | 2.12 | החלטה על שימוש באבטיפוס ובכלים ממוכנים אחרים |  | 1d? | 2005-03-17 | 2005-03-17 | 16 | 8d |  | מנהל הפרויקט | 8h |
| 19 | 2.13 | שיקוף ראשון | milestone | 1d? | 2005-03-17 | 2005-03-17 | 17 | 0d |  | מנהל הפרויקט | 8h |
| 20 | 3 | **מעברים נוספים - אפיון בסבבים** |  | 5d? | 2005-03-18 | 2005-03-24 |  | 0d |  | מנהל הפרויקט | 128h |
| 21 | 3.1 | בניית אבטיפוס |  | 1d? | 2005-03-18 | 2005-03-18 | 19 | 7d |  | צוות הפרויקט | 8h |
| 22 | 3.2 | הגדרה ראשונית של רכיבי הטכנולוגיה והמימוש |  | 1d? | 2005-03-18 | 2005-03-18 | 19 | 6d | 0d | מהנדס הפרויקט | 8h |
| 23 | 3.3 | השלמת הגדרת היישום - ניתוח מערכת II |  | 1d? | 2005-03-18 | 2005-03-18 | 19 | 0d |  | מנתח המערכת | 8h |
| 24 | 3.4 | הגדרה חוזרת של רכיבי הטכנולוגיה |  | 1d? | 2005-03-21 | 2005-03-21 | 22 | 6d |  | מהנדס הפרויקט | 8h |
| 25 | 3.5 | הגדרה חוזרת של רכיב המימוש |  | 1d? | 2005-03-21 | 2005-03-21 | 23 | 5d | 0d | מנתח המערכת | 8h |
| 26 | 3.6 | כתיבה ראשונה של מסמך האפיון |  | 1d? | 2005-03-22 | 2005-03-22 | 25 | 5d |  | מנתח המערכת | 8h |
| 27 | 3.7 | עריכת אומדן עלויות וחקר ישימות |  | 1d? | 2005-03-21 | 2005-03-21 | 23 | 0d |  | מנהל הפרויקט | 8h |
| 28 | 3.8 | סגירת רכיבי x.98 - ניתוח חלופות |  | 1d? | 2005-03-22 | 2005-03-22 | 27 | 0d |  | מנהל הפרויקט | 8h |
| 29 | 3.9 | ביצוע שיקופים לאפיון המערכת |  | 1d? | 2005-03-23 | 2005-03-23 | 28 | 0d |  | מנהל הפרויקט | 8h |
| 30 | 3.10 | דיון ממצה בצוות המקצועי | milestone | 0d | 2005-03-23 | 2005-03-23 | 29 | 0d |  | צוות הפרויקט |  |
| 31 | 3.11 | בדיקה של אבטחת איכות |  | 1d? | 2005-03-24 | 2005-03-24 | 30 | 3d |  | אבטחת איכות | 8h |
| 32 | 3.12 | חזרה על פעילויות 17-28 בעקבות הערות |  | 1d? | 2005-03-24 | 2005-03-24 | 30 | 0d |  | צוות הפרויקט | 8h |

| ID | WBS | Task | Type | Duration | Start | Finish | Predecessors | Total slack | Resources | Work |
| --- | --- | --- | --- | --- | --- | --- | --- | --- | --- | --- |
| 33 | 4 | **מצגות וסיכום האפיון** |  | 3d? | 2005-03-25 | 2005-03-29 |  | 0d | מנהל הפרויקט | 56h |
| 34 | 4.1 | עריכה סופית של מסמך האפיון והפצתו |  | 1d? | 2005-03-25 | 2005-03-25 | 32 | 0d | מנתח המערכת | 8h |
| 35 | 4.2 | דיון בצוות המעקב המינהלי | milestone | 1d? | 2005-03-28 | 2005-03-28 | 34 | 1d | ועדת היגוי | 8h |
| 36 | 4.3 | הפצת מסמך האפיון |  | 1d? | 2005-03-28 | 2005-03-28 | 34 | 0d | מנהל הפרויקט | 8h |
| 37 | 4.4 | החלטה על המשך הפרויקט | milestone | 1d? | 2005-03-29 | 2005-03-29 | 36 | 0d | ועדת היגוי | 8h |
