# עיצוב ובניה

Schedule from MS Project, 2005-03-07 to 2005-04-13.
<שם המערכת>
<שם הארגון>

## Calendars

- Standard: Mon-Fri 08:00-12:00, 13:00-17:00; Sat-Sun off.

## Resources

| Resource |
| --- |
| מנהל הפרויקט |
| מנתח המערכת |
| מהנדס המערכת |
| צוות הפיתוח |
| אבטחת איכות |
| DBA |
| ועדת היגוי |

## Schedule

| ID | WBS | Task | Type | Duration | Start | Finish | Predecessors | Total slack | Free slack | Resources | Work |
| --- | --- | --- | --- | --- | --- | --- | --- | --- | --- | --- | --- |
| 1 | 1 | **פעילויות עיצוב** |  | 9d? | 2005-03-07 | 2005-03-17 |  | 0d |  |  | 120h |
| 2 | 1.1 | תיקיית הפרויקט |  | 1d? | 2005-03-07 | 2005-03-07 |  | 0d |  | מנהל הפרויקט | 8h |
| 3 | 1.2 | הקמת צוותי עבודה |  | 1d? | 2005-03-08 | 2005-03-08 | 2 | 21d | 0d | מנהל הפרויקט | 8h |
| 4 | 1.3 | ארגון החומר ובניית תיק עיצוב ראשוני |  | 1d? | 2005-03-08 | 2005-03-08 | 2 | 0d |  | מנתח המערכת | 8h |
| 5 | 1.4 | בניית תוכנית עבודה |  | 1d? | 2005-03-09 | 2005-03-09 | 3 | 21d | 0d | מנהל הפרויקט | 8h |
| 6 | 1.5 | השלמת ראיונות |  | 1d? | 2005-03-09 | 2005-03-09 | 4 | 0d |  | מנתח המערכת | 8h |
| 7 | 1.6 | החלטה סופית על כלים |  | 1d? | 2005-03-10 | 2005-03-10 | 5 | 21d | 0d | מנהל הפרויקט | 8h |
| 8 | 1.7 | ניהול תצורה I |  | 1d? | 2005-03-11 | 2005-03-11 | 7 | 21d | 0d | מהנדס המערכת | 8h |
| 9 | 1.8 | אבטחת איכות |  | 1d? | 2005-03-14 | 2005-03-14 | 8 | 21d | 0d | אבטחת איכות | 8h |
| 10 | 1.9 | בניית אבטיפוס |  | 1d? | 2005-03-15 | 2005-03-15 | 9 | 21d |  | צוות הפיתוח | 8h |
| 11 | 1.10 | סגירת האפיון ונקודות פתוחות | milestone | 1d? | 2005-03-10 | 2005-03-10 | 6 | 0d |  | ועדת היגוי | 8h |
| 12 | 1.11 | השלמת רכיבי עיצוב מובהקים |  | 1d? | 2005-03-11 | 2005-03-11 | 11 | 0d |  | מנתח המערכת | 8h |
| 13 | 1.12 | בדיקה לשינויים ברכיבים לוגיים ופונקציונאליים |  | 1d? | 2005-03-14 | 2005-03-14 | 12 | 0d |  | מנתח המערכת | 8h |
| 14 | 1.13 | עדכון תיק (מסמך) העיצוב |  | 1d? | 2005-03-15 | 2005-03-15 | 13 | 0d |  | מנתח המערכת | 8h |
| 15 | 1.14 | שיקופים ובדיקות אבטחת איכות |  | 1d? | 2005-03-16 | 2005-03-16 | 14 | 20d |  | אבטחת איכות | 8h |
| 16 | 1.15 | חזרה על פעילויות 11 - 14 |  | 1d? | 2005-03-16 | 2005-03-16 | 14 | 0d |  |  |  |
| 17 | 1.16 | אישור תיק העיצוב | milestone | 1d? | 2005-03-17 | 2005-03-17 | 16 | 0d |  | ועדת היגוי | 8h |
| 18 | 1.17 | ניהול תצורה II |  | 1d? | 2005-03-17 | 2005-03-17 | 16 | 19d |  |  |  |
| 19 | 2 | **פעילויות בנייה - קידוד** |  | 11d? | 2005-03-18 | 2005-04-01 |  | 0d |  |  | 96h |
| 20 | 2.1 | העמדת מחשב לפיתוח המערכת |  | 1d? | 2005-03-18 | 2005-03-18 | 17 | 0d |  | מהנדס המערכת | 8h |
| 21 | 2.2 | נהלים וסביבת העבודה |  | 1d? | 2005-03-18 | 2005-03-18 | 17 | 18d |  | מנתח המערכת | 8h |
| 22 | 2.3 | בניית מילון הנתונים - רכיב 2.13 |  | 1d? | 2005-03-21 | 2005-03-21 | 20 | 0d |  | DBA | 8h |
| 23 | 2.4 | קידוד שגרות כלליות - רכיב 2.9 |  | 1d? | 2005-03-22 | 2005-03-22 | 22 | 0d |  | צוות הפיתוח | 8h |
| 24 | 2.5 | בניית טבלאות כלליות - רכיב 2.10 |  | 1d? | 2005-03-23 | 2005-03-23 | 23 | 0d |  | צוות הפיתוח | 8h |
| 25 | 2.6 | בניית בסיס הנתונים הפיסי |  | 1d? | 2005-03-24 | 2005-03-24 | 24 | 0d |  | צוות הפיתוח | 8h |
| 26 | 2.7 | בניית עץ המסכים - רכיב 2.4.1 |  | 1d? | 2005-03-25 | 2005-03-25 | 25 | 0d |  | צוות הפיתוח | 8h |
| 27 | 2.8 | קידוד מסכים - רכיב 2.4.2 |  | 1d? | 2005-03-28 | 2005-03-28 | 26 | 0d |  | צוות הפיתוח | 8h |
| 28 | 2.9 | קידוד תכניות - רכיב 2.7 מודולים |  | 1d? | 2005-03-29 | 2005-03-29 | 27 | 0d |  | צוות הפיתוח | 8h |
| 29 | 2.10 | טעינת הקבצים בנתונים |  | 1d? | 2005-03-30 | 2005-03-30 | 28 | 0d |  | צוות הפיתוח | 8h |
| 30 | 2.11 | ביצוע בדיקות יחידה |  | 1d? | 2005-03-31 | 2005-03-31 | 29 | 0d |  | צוות הפיתוח | 8h |
| 31 | 2.12 | ניסויי תת-מערכת טריוויאליים |  | 1d? | 2005-04-01 | 2005-04-01 | 30 | 0d |  | צוות הפיתוח | 8h |

| ID | WBS | Task | Duration | Start | Finish | Predecessors | Total slack | Resources | Work |
| --- | --- | --- | --- | --- | --- | --- | --- | --- | --- |
| 32 | 3 | **פעילויות שילוב** | 2d? | 2005-04-04 | 2005-04-05 |  | 0d |  | 16h |
| 33 | 3.1 | ניהול תצורה III | 1d? | 2005-04-04 | 2005-04-04 | 31 | 0d | מהנדס המערכת | 8h |
| 34 | 3.2 | איסוף ושילוב | 1d? | 2005-04-05 | 2005-04-05 | 33 | 0d | מנתח המערכת | 8h |
| 35 | 4 | **בדיקות שילוב - אינטגרציה** | 6d? | 2005-04-06 | 2005-04-13 |  | 0d |  | 48h |
| 36 | 4.1 | פתיחה וסגירה על מחשב הפיתוח | 1d? | 2005-04-06 | 2005-04-06 | 34 | 0d | צוות הפיתוח | 8h |
| 37 | 4.2 | ניסוי תת-מערכת | 1d? | 2005-04-07 | 2005-04-07 | 36 | 0d | צוות הפיתוח | 8h |
| 38 | 4.3 | העמדת מחשב הייצור | 1d? | 2005-04-08 | 2005-04-08 | 37 | 0d | צוות הפיתוח | 8h |
| 39 | 4.4 | פריקה וטעינה, הקמת המערכת | 1d? | 2005-04-11 | 2005-04-11 | 38 | 0d | צוות הפיתוח | 8h |
| 40 | 4.5 | פתיחה וסגירה על מחשב הייצור | 1d? | 2005-04-12 | 2005-04-12 | 39 | 0d | צוות הפיתוח | 8h |
| 41 | 4.6 | עדכון תיק העיצוב - ניהול תצורה IV | 1d? | 2005-04-13 | 2005-04-13 | 40 | 0d | מנתח המערכת | 8h |
